Schedule from MS Project, 2008-01-08 to 2008-01-24, costs in р..
home

## Calendars

- Стандартный: Mon-Fri 09:00-13:00, 14:00-18:00; Sat-Sun off.

## Resources

| Resource | Unit | Rate |
| --- | --- | --- |
| Трудозатраты |  |  |
| 000-1001-5 Рабочие-строители (средний разряд 1.5) | чел.ч. | 48.73 |
| Трудозатраты |  |  |
| 000-1002-0 Рабочие-строители (средний разряд 2.0) | чел.ч. | 50.76 |
| Трудозатраты |  |  |
| 000-1003-1 Рабочие-строители (средний разряд 3.1) | чел.ч. | 56.21 |
| Трудозатраты |  |  |
| 000-1003-2 Рабочие-строители (средний разряд 3.2) | чел.ч. | 56.89 |
| Трудозатраты |  |  |
| 000-1003-5 Рабочие-строители (средний разряд 3.5) | чел.ч. | 59.03 |
| Трудозатраты |  |  |
| 000-1003-6 Рабочие-строители (средний разряд 3.6) | чел.ч. | 59.77 |
| Трудозатраты |  |  |
| 000-1004-6 Рабочие-строители (средний разряд 4.6) | чел.ч. | 68.35 |
| Трудозатраты |  |  |
| 000-1005-0 Рабочие-строители (средний разряд 5.0) | чел.ч. | 72.15 |
| Трудозатраты |  |  |
| 000-1006-0 Рабочие-строители (средний разряд 6.0) | чел.ч. | 84.04 |
| Трудозатраты |  |  |
| 02-1141 Краны на автомобильном ходу при работе на других видах строительства (кроме магистральных трубопроводов) 10 т | маш.ч. | 313.76 |
| Трудозатраты |  |  |
| 04-0502 Установки для сварки ручной дуговой (постоянного тока) | маш.ч. | 23.38 |
| Трудозатраты |  |  |
| 04-0504 Аппараты для газовой сварки и резки | маш.ч. | 4.2 |
| Трудозатраты |  |  |
| 101-0218 Глицерин синтетический | т. | 92811.6 |
| Трудозатраты |  |  |
| 101-0312 Карбид кальция для кусков 50/80 | т. | 17697.1 |
| Трудозатраты |  |  |
| 101-0324 Кислород технический газообразный | м3. | 36.82 |
| Трудозатраты |  |  |
| 101-0596 Мастика битумно-кукерсольная холодная | т. | 17363.6 |
| Трудозатраты |  |  |
| 101-1355 Цемент гипсоглиноземистый расширяющийся | т. | 5500.6 |
| Трудозатраты |  |  |
| 101-1513 Электроды диаметром 4 мм Э42 | т. | 39323.2 |
| Трудозатраты |  |  |
| 101-1602 Ацетилен газообразный технический | м3. | 268.38 |
| Трудозатраты |  |  |
| 101-1703 Прокладки резиновые (пластина техническая прессованная) | кг. | 127.79 |
| Трудозатраты |  |  |
| 101-1705 Пакля пропитанная | кг. | 33.24 |
| Трудозатраты |  |  |
| 101-1941 Герметик У-30м | кг. | 162.9 |
| Трудозатраты |  |  |
| 113-0003 Ацетон технический сорт I | т. | 66164 |
| Трудозатраты |  |  |
| 113-0180 Спирт этиловый ректификованный технический, сорт I | т. | 144844 |
| Трудозатраты |  |  |
| 15-0202 Агрегаты сварочные двухпостовые для ручной сварки на тракторе 79 кВт (108 л.с.) | маш.ч. | 397.63 |
| Трудозатраты |  |  |
| 201-0780 Прочие индивидуальные сварные конструкции, масса сборочной единицы от 0.501 до 1.0 т | т. | 39788 |
| Трудозатраты |  |  |
| 201-0782 Щиты опалубки металлические (опорная площадка под лебедку) | т. | 48314 |
| Трудозатраты |  |  |
| 300-0040 Болты с гайками и шайбами для санитарно-технических работ, диаметром 16 мм | т. | 57624 |
| Трудозатраты |  |  |
| 300-0969 Фланцы стальные плоские приварные из стали ВСт3сп2, ВСт3сп3 давлением 1.0 МПа (10 кгс/см2), диаметром 100 мм | шт.. | 316.4 |
| Трудозатраты |  |  |
| 31-0102 Hасосы для водопонижения и водоотлива 4 кВт | маш.ч. | 21.83 |
| Трудозатраты |  |  |
| 38-0105 Машины промывочные на базе автомобиля 'Мерседес' | маш.ч. | 897.94 |
| Трудозатраты |  |  |
| 38-0111 Оборудование инспекционное на базе микроавтобуса 'Фольксваген' | маш.ч. | 785 |
| Трудозатраты |  |  |
| 39-0405 Электростанции 'Хонда' | маш.ч. | 102.42 |
| Трудозатраты |  |  |
| 39-0501 Мотолебедки 20 т | маш.ч. | 452.23 |
| Трудозатраты |  |  |
| 39-1701 Компрессоры 'ATLAS COPCO' | маш.ч. | 185.14 |
| Трудозатраты |  |  |
| 39-2107 Пневмопробойники 'Олимп' | маш.ч. | 332.58 |
| Трудозатраты |  |  |
| 39-2208 Агрегаты сварочные 'Ротенбергер' | маш.ч. | 122.93 |
| Трудозатраты |  |  |
| 40-0001 Автомобили бортовые грузоподъемностью до 5 т | маш.ч. | 310.2 |
| Трудозатраты |  |  |
| 40-0101 Тягачи седельные 12 т | маш.ч. | 399.01 |
| Трудозатраты |  |  |
| 40-0111 Полуприцепы общего назначения 12 т | маш.ч. | 38.14 |
| Трудозатраты |  |  |
| 402-0004 Раствор готовый кладочный цементный, марка 100 | м3. | 1457.04 |
| Трудозатраты |  |  |
| 411-0001 Вода | м3. | 10.08 |

## Schedule

| ID | WBS | Task | Type | Duration | Start | Finish | Predecessors | Total slack | Free slack | Resources | Cost |
| --- | --- | --- | --- | --- | --- | --- | --- | --- | --- | --- | --- |
| 1 | 1 | **1 Земляные работы** |  | 12.3d | 2008-01-08 | 2008-01-24 |  | 0d |  |  | 1,940.74 |
| 2 | 1.1 | 2 Е01-02-057-2 Разработка грунта вручную в траншеях глубиной до 2 м без креплений с откосами, группа грунтов: 2 |  | 0.5d | 2008-01-08 | 2008-01-08 |  | 0d |  | 000-1002-0 Рабочие-строители (средний разряд 2.0) [24.64 чел.ч.] | 1,250.73 |
| 3 | 1.2 | 3 Е01-02-061-1 Засыпка вручную траншей, пазух котлованов и ям, группа грунтов: 1 |  | 3d | 2008-01-21 | 2008-01-24 | 11 | 0d |  | 000-1001-5 Рабочие-строители (средний разряд 1.5) [14.16 чел.ч.] | 690.02 |
| 4 | 2 | **4 Демонтажные работы** |  | 0.3d | 2008-01-08 | 2008-01-08 | 2 | 0d |  |  | 110.86 |
| 5 | 2.1 | 5 Е66-26-2 Демонтаж задвижек диаметром до 100 мм |  | 0.3d | 2008-01-08 | 2008-01-08 | 2 | 0d |  | 40-0001 Автомобили бортовые грузоподъемностью до 5 т [0.12 маш.ч.]; 000-1003-1 Рабочие-строители (средний разряд 3.1) [1.31 чел.ч.] | 110.86 |
| 6 | 3 | **6 Замена трубопровода** |  | 8.5d | 2008-01-08 | 2008-01-21 |  | 0d |  |  | 39,071.62 |
| 7 | 3.1 | 7 Е52-11-3 Водоотлив слитой воды электрическими (механическими) насосами |  | 0.5d | 2008-01-08 | 2008-01-09 | 5 | 0d |  | 000-1002-0 Рабочие-строители (средний разряд 2.0) [0.4 чел.ч.]; 31-0102 Hасосы для водопонижения и водоотлива 4 кВт [0.08 маш.ч.] | 22.05 |
| 8 | 3.2 | 8 Е22-03-014-3 Приварка фланцев к трубопроводам диаметром 100 мм |  | 0.5d | 2008-01-15 | 2008-01-15 | 9 | 0d |  | 000-1005-0 Рабочие-строители (средний разряд 5.0) [2.78 чел.ч.]; 15-0202 Агрегаты сварочные двухпостовые для ручной сварки на тракторе 79 кВт (108 л.с.) [1.81 маш.ч.]; 101-1513 Электроды диаметром 4 мм Э42; 300-0969 Фланцы стальные плоские приварные из стали ВСт3сп2, ВСт3сп3 давлением 1.0 МПа (10 кгс/см2), диаметром 100 мм [3 шт..] | 1,869.49 |
| 9 | 3.3 | 9 Е66-31-2 Бестраншейная замена труб полиэтиленовыми трубами с изменением диаметра с dу 100 мм на dн 110 мм |  | 4d | 2008-01-09 | 2008-01-15 | 7 | 0d |  | 39-1701 Компрессоры 'ATLAS COPCO' [4.14 маш.ч.]; 39-2107 Пневмопробойники 'Олимп' [4.14 маш.ч.]; 39-2208 Агрегаты сварочные 'Ротенбергер' [3.8 маш.ч.]; 40-0001 Автомобили бортовые грузоподъемностью до 5 т [0.21 маш.ч.]; 40-0101 Тягачи седельные 12 т [0.55 маш.ч.]; 40-0111 Полуприцепы общего назначения 12 т [0.55 маш.ч.]; 101-0218 Глицерин синтетический; 113-0180 Спирт этиловый ректификованный технический, сорт I; 201-0780 Прочие индивидуальные сварные конструкции, масса сборочной единицы от 0.501 до 1.0 т [0.02 т.]; 201-0782 Щиты опалубки металлические (опорная площадка под лебедку) [0.01 т.]; 000-1004-6 Рабочие-строители (средний разряд 4.6) [87.11 чел.ч.]; 02-1141 Краны на автомобильном ходу при работе на других видах строительства (кроме магистральных трубопроводов) 10 т [16.28 маш.ч.]; 39-0405 Электростанции 'Хонда' [3.8 маш.ч.]; 39-0501 Мотолебедки 20 т [5.87 маш.ч.] | 18,300.74 |
| 10 | 3.4 | 10 Стоимость Труба ПЭ 100 PN 10 d 100 | milestone | 0d | 2008-01-09 | 2008-01-09 | 9SS | 11d |  |  |  |
| 11 | 3.5 | 11 Е66-27-1 Промывка трубопроводов диаметром до 150 мм |  | 1d | 2008-01-18 | 2008-01-21 | 16 | 0d |  | 000-1006-0 Рабочие-строители (средний разряд 6.0) [44.49 чел.ч.]; 31-0102 Hасосы для водопонижения и водоотлива 4 кВт [24.84 маш.ч.]; 38-0105 Машины промывочные на базе автомобиля 'Мерседес' [9.32 маш.ч.]; 39-0405 Электростанции 'Хонда' [24.84 маш.ч.]; 411-0001 Вода [34.56 м3.] | 15,542.48 |
| 12 | 3.6 | 12 Е66-28-1 Телевизионное инспекционное обследование трубопровода после промывки с одновременной сушкой диаметром до 150 мм |  | 1d | 2008-01-15 | 2008-01-16 | 8 | 0d |  | 000-1006-0 Рабочие-строители (средний разряд 6.0) [7 чел.ч.]; 31-0102 Hасосы для водопонижения и водоотлива 4 кВт [4.14 маш.ч.]; 38-0111 Оборудование инспекционное на базе микроавтобуса 'Фольксваген' [1.38 маш.ч.]; 39-0405 Электростанции 'Хонда' [4.14 маш.ч.]; 39-1701 Компрессоры 'ATLAS COPCO' [1.38 маш.ч.] | 2,441.47 |
| 13 | 3.7 | 13 Е29-01-253-2 Установка гильз из стальных труб диаметром: 150 мм |  | 1d | 2008-01-15 | 2008-01-16 | 9 | 5d | 0d | 000-1003-5 Рабочие-строители (средний разряд 3.5) [2.56 чел.ч.]; 04-0502 Установки для сварки ручной дуговой (постоянного тока) [0.01 маш.ч.]; 04-0504 Аппараты для газовой сварки и резки [0.01 маш.ч.]; 101-0312 Карбид кальция для кусков 50/80; 101-0324 Кислород технический газообразный [0.01 м3.]; 101-1513 Электроды диаметром 4 мм Э42; 101-1602 Ацетилен газообразный технический | 151.76 |
| 14 | 3.8 | 14 Е52-15-1 Герметизация гильз |  | 0.5d | 2008-01-16 | 2008-01-16 | 13 | 5d | 0d | 000-1003-2 Рабочие-строители (средний разряд 3.2) [1.48 чел.ч.]; 40-0001 Автомобили бортовые грузоподъемностью до 5 т; 101-1705 Пакля пропитанная [0.28 кг.]; 101-1941 Герметик У-30м [0.42 кг.]; 113-0003 Ацетон технический сорт I; 402-0004 Раствор готовый кладочный цементный, марка 100 | 161.92 |
| 15 | 3.9 | 15 Е16-07-006-2 Заделка гильз с наружней стороны при проходе через фундаменты или стены подвала диаметром до 200 мм |  | 0.5d | 2008-01-16 | 2008-01-17 | 14 | 5d |  | 000-1003-5 Рабочие-строители (средний разряд 3.5) [6.24 чел.ч.]; 101-0596 Мастика битумно-кукерсольная холодная; 101-1355 Цемент гипсоглиноземистый расширяющийся; 101-1705 Пакля пропитанная [0.01 кг.] | 368.68 |
| 16 | 3.10 | 16 Е22-03-007-2 Установка задвижек или клапанов обратных стальных диаметром 100 мм |  | 1.5d | 2008-01-16 | 2008-01-18 | 12 | 0d |  | 000-1003-6 Рабочие-строители (средний разряд 3.6) [3.03 чел.ч.]; 40-0001 Автомобили бортовые грузоподъемностью до 5 т [0.07 маш.ч.]; 101-1703 Прокладки резиновые (пластина техническая прессованная) [0.08 кг.]; 300-0040 Болты с гайками и шайбами для санитарно-технических работ, диаметром 16 мм | 213.04 |
| 17 | 3.11 | 17 Стоимость Задвижка стальная. 30с15нж Ду 100 | milestone | 0d | 2008-01-16 | 2008-01-16 | 16SS | 5.5d |  |  |  |
